# Kalle Kuja - Autotalli

How a schedule from MS Project changed from version to version. A marks actual dates.

## Version 1 (saved 2015-10-29, file Kalle Kuja - autotalli 4.mpp)

| ID | WBS | Task | Duration | Start | Finish | Total float |
| --- | --- | --- | --- | --- | --- | --- |
| 1 | 1 | **Kalle Kuja - autotalli** | 0d | 2016-07-04 | 2016-07-04 |  |
| 2 |  | PROJEKTIN ALOITUS | 0d | 2016-07-04 | 2016-07-04 | 4d |
| 3 | 1.2 | **PERUSTUSTYÖT** | 3d | 2016-07-04 | 2016-07-06 | 1d |
| 4 |  | Rakennuspaikan merkitseminen | 1d | 2016-07-04 | 2016-07-04 | 3d |
| 5 |  | Perustusten kaivuu | 5.5h | 2016-07-04 | 2016-07-04 | 3.27d |
| 6 |  | Valurungon laudoitus | 2.5d | 2016-07-04 | 2016-07-06 | 1.5d |
| 7 |  | Raudoitustyö | 3d | 2016-07-04 | 2016-07-06 | 1d |
| 8 |  | Raudoitustarkastus | 2h | 2016-07-04 | 2016-07-04 | 3.73d |
| 9 |  | Perustusten valu | 3h | 2016-07-04 | 2016-07-04 | 3.6d |
| 10 |  | PERUSTUSTYÖT VALMIIT | 0d | 2016-07-04 | 2016-07-04 | 4d |
| 11 | 1.4 | **RUNKOTYÖT** | 4d | 2016-07-04 | 2016-07-07 | 0d |
| 12 |  | Valurungon purkaminen | 5h | 2016-07-04 | 2016-07-04 | 3.33d |
| 13 |  | Sadevesiviemärien asentaminen | 4h | 2016-07-04 | 2016-07-04 | 3.47d |
| 14 |  | Maatyöt (pihan viimeistely) | 5h | 2016-07-04 | 2016-07-04 | 3.33d |
| 15 |  | Kantavan rungon pystytys | 4d | 2016-07-04 | 2016-07-07 | 0d |
| 16 |  | RUNKOTYÖT VALMIIT | 0d | 2016-07-04 | 2016-07-04 | 4d |
| 17 | 1.6 | **KATTOTYÖT** | 2.5d | 2016-07-04 | 2016-07-06 | 1.5d |
| 18 |  | Kattotuolien asennus | 2.5d | 2016-07-04 | 2016-07-06 | 9.13d |
| 19 |  | Aluskatteen asnnus | 1d | 2016-07-04 | 2016-07-04 | 10.63d |
| 20 |  | Kattotiilien asennus | 1d | 2016-07-04 | 2016-07-04 | 10.63d |
| 21 |  | KATTOTYÖT VALMIIT | 0d | 2016-07-04 | 2016-07-04 | 11.63d |
| 22 | 1.8 | **VERHOUSTYÖT** | 3d | 2016-07-04 | 2016-07-06 | 1d |
| 23 |  | Ulkoverhouksen tekeminen | 2d | 2016-07-04 | 2016-07-05 | 9.63d |
| 24 |  | Sisäkaton asentaminen | 1d | 2016-07-04 | 2016-07-04 | 10.63d |
| 25 |  | Sisäverhouksen tekeminen | 3d | 2016-07-04 | 2016-07-06 | 8.63d |
| 26 |  | Sadevesikourujen asennus | 1d | 2016-07-04 | 2016-07-04 | 10.63d |
| 27 |  | Sähköasennukset | 1d | 2016-07-04 | 2016-07-04 | 10.63d |
| 28 |  | Valaisimien asennus | 2h | 2016-07-04 | 2016-07-04 | 11.37d |
| 29 |  | Maalaustyöt | 3d | 2016-07-04 | 2016-07-06 | 8.63d |
| 30 |  | VERHOUSTYÖT VALMIIT | 0d | 2016-07-04 | 2016-07-04 | 11.63d |
| 31 |  | PROJEKTI VALMIS | 2h | 2016-07-04 | 2016-07-04 | 3.73d |

## Version 2 (saved 2015-10-29, file Kalle Kuja - autotalli 5.mpp)

Last finish 2016-07-07 → 2016-08-02 (+26d).

Changed:

| ID | Task | Start | Finish | Duration | Total float | Predecessors |
| --- | --- | --- | --- | --- | --- | --- |
| 3 | **PERUSTUSTYÖT** |  | 2016-07-06 → 2016-07-13 (+7d) | 3d → 7.9d | 1d → 0d |  |
| 4 | Rakennuspaikan merkitseminen |  |  |  | 3d → 0d | none → 2 |
| 5 | Perustusten kaivuu | 2016-07-04 → 2016-07-05 (+1d) | 2016-07-04 → 2016-07-05 (+1d) |  | 3.27d → 0d | none → 4 |
| 6 | Valurungon laudoitus | 2016-07-04 → 2016-07-05 (+1d) | 2016-07-06 → 2016-07-08 (+2d) |  | 1.5d → 0d | none → 5 |
| 7 | Raudoitustyö | 2016-07-04 → 2016-07-08 (+4d) | 2016-07-06 → 2016-07-13 (+7d) |  | 1d → 0d | none → 6 |
| 8 | Raudoitustarkastus | 2016-07-04 → 2016-07-13 (+9d) | 2016-07-04 → 2016-07-13 (+9d) |  | 3.73d → 0d | none → 7 |
| 9 | Perustusten valu | 2016-07-04 → 2016-07-13 (+9d) | 2016-07-04 → 2016-07-13 (+9d) |  | 3.6d → 0d | none → 8 |
| 10 | PERUSTUSTYÖT VALMIIT | 2016-07-04 → 2016-07-13 (+9d) | 2016-07-04 → 2016-07-13 (+9d) |  | 4d → 0d | none → 3FF, 9 |
| 11 | **RUNKOTYÖT** | 2016-07-04 → 2016-07-13 (+9d) | 2016-07-07 → 2016-07-20 (+13d) | 4d → 4.67d |  | none → 10 |
| 12 | Valurungon purkaminen | 2016-07-04 → 2016-07-13 (+9d) | 2016-07-04 → 2016-07-14 (+10d) |  | 3.33d → 0d | none → 9 |
| 13 | Sadevesiviemärien asentaminen | 2016-07-04 → 2016-07-14 (+10d) | 2016-07-04 → 2016-07-15 (+11d) |  |  | none → 12 |
| 14 | Maatyöt (pihan viimeistely) | 2016-07-04 → 2016-07-14 (+10d) | 2016-07-04 → 2016-07-15 (+11d) |  |  | none → 12 |
| 15 | Kantavan rungon pystytys | 2016-07-04 → 2016-07-14 (+10d) | 2016-07-07 → 2016-07-20 (+13d) |  |  | none → 12 |
| 16 | RUNKOTYÖT VALMIIT | 2016-07-04 → 2016-07-20 (+16d) | 2016-07-04 → 2016-07-20 (+16d) |  | 4d → 0d | none → 11FF |
| 17 | **KATTOTYÖT** | 2016-07-04 → 2016-07-20 (+16d) | 2016-07-06 → 2016-07-27 (+21d) | 2.5d → 4.5d | 1.5d → 0d | none → 16 |
| 18 | Kattotuolien asennus | 2016-07-04 → 2016-07-20 (+16d) | 2016-07-06 → 2016-07-25 (+19d) |  | 9.13d → 0d | none → 15 |
| 19 | Aluskatteen asnnus | 2016-07-04 → 2016-07-25 (+21d) | 2016-07-04 → 2016-07-26 (+22d) |  | 10.63d → 1d | none → 18 |
| 20 | Kattotiilien asennus | 2016-07-04 → 2016-07-26 (+22d) | 2016-07-04 → 2016-07-27 (+23d) |  | 10.63d → 4.27d | none → 19 |
| 21 | KATTOTYÖT VALMIIT | 2016-07-04 → 2016-07-27 (+23d) | 2016-07-04 → 2016-07-27 (+23d) |  | 11.63d → 4.27d | none → 17FF, 20 |
| 22 | **VERHOUSTYÖT** | 2016-07-04 → 2016-07-25 (+21d) | 2016-07-06 → 2016-08-02 (+27d) | 3d → 6.27d | 1d → 0d |  |
| 23 | Ulkoverhouksen tekeminen | 2016-07-04 → 2016-07-25 (+21d) | 2016-07-05 → 2016-07-27 (+22d) |  | 9.63d → 0d | none → 18 |
| 24 | Sisäkaton asentaminen | 2016-07-04 → 2016-07-27 (+23d) | 2016-07-04 → 2016-07-28 (+24d) |  | 10.63d → 0d | none → 19, 23 |
| 25 | Sisäverhouksen tekeminen | 2016-07-04 → 2016-07-28 (+24d) | 2016-07-06 → 2016-08-02 (+27d) |  | 8.63d → 0d | none → 24, 27 |
| 26 | Sadevesikourujen asennus | 2016-07-04 → 2016-07-27 (+23d) | 2016-07-04 → 2016-07-28 (+24d) |  | 10.63d → 3.27d | none → 23 |
| 27 | Sähköasennukset | 2016-07-04 → 2016-07-27 (+23d) | 2016-07-04 → 2016-07-28 (+24d) |  | 10.63d → 0d | none → 23 |
| 28 | Valaisimien asennus | 2016-07-04 → 2016-08-02 (+29d) | 2016-07-04 → 2016-08-02 (+29d) |  | 11.37d → 0d | none → 24, 25 |
| 29 | Maalaustyöt | 2016-07-04 → 2016-07-27 (+23d) | 2016-07-06 → 2016-08-01 (+26d) |  | 8.63d → 1.27d | none → 23 |
| 30 | VERHOUSTYÖT VALMIIT | 2016-07-04 → 2016-08-02 (+29d) | 2016-07-04 → 2016-08-02 (+29d) |  | 11.63d → 0d | none → 22FF, 29 |
| 31 | PROJEKTI VALMIS | 2016-07-04 → 2016-08-02 (+29d) | 2016-07-04 → 2016-08-02 (+29d) |  | 3.73d → 0d | none → 1, 30 |

## Version 3 (saved 2015-10-29, file Kalle Kuja - autotalli 6.mpp)

Last finish 2016-08-02 → 2016-07-29 (-4d).

Changed:

| ID | Task | Start | Finish | Duration | Total float | Predecessors | Other |
| --- | --- | --- | --- | --- | --- | --- | --- |
| 3 | **PERUSTUSTYÖT** |  | 2016-07-13 → 2016-07-08 (-5d) | 7.9d → 5d |  |  |  |
| 5 | Perustusten kaivuu | 2016-07-05 → 2016-07-04 (-1d) | 2016-07-05 → 2016-07-04 (-1d) |  | 0d → 0.1d | 4 → 4FF |  |
| 6 | Valurungon laudoitus |  | 2016-07-08 → 2016-07-07 (-1d) |  | 0d → 0.1d |  |  |
| 7 | Raudoitustyö | 2016-07-08 → 2016-07-05 (-3d) | 2016-07-13 → 2016-07-08 (-5d) |  | 0d → 0.1d | 6 → 6FS-2d |  |
| 8 | Raudoitustarkastus | 2016-07-13 → 2016-07-08 (-5d) | 2016-07-13 → 2016-07-08 (-5d) |  |  | 7 → 7FF | constraint none → must start on 2016-07-08 |
| 9 | Perustusten valu | 2016-07-13 → 2016-07-08 (-5d) | 2016-07-13 → 2016-07-08 (-5d) |  |  |  | constraint none → must finish on 2016-07-08 |
| 10 | PERUSTUSTYÖT VALMIIT | 2016-07-13 → 2016-07-08 (-5d) | 2016-07-13 → 2016-07-08 (-5d) |  | 0d → 0.33d |  |  |
| 11 | **RUNKOTYÖT** | 2016-07-13 → 2016-07-11 (-2d) | 2016-07-20 → 2016-07-15 (-5d) |  | 0d → 0.33d |  |  |
| 12 | Valurungon purkaminen | 2016-07-13 → 2016-07-11 (-2d) | 2016-07-14 → 2016-07-11 (-3d) |  | 0d → 0.33d | 9 → 9FS+2ed |  |
| 13 | Sadevesiviemärien asentaminen | 2016-07-14 → 2016-07-11 (-3d) | 2016-07-15 → 2016-07-12 (-3d) |  | 3.47d → 3.8d |  |  |
| 14 | Maatyöt (pihan viimeistely) | 2016-07-14 → 2016-07-11 (-3d) | 2016-07-15 → 2016-07-12 (-3d) |  | 3.33d → 3.67d |  |  |
| 15 | Kantavan rungon pystytys | 2016-07-14 → 2016-07-11 (-3d) | 2016-07-20 → 2016-07-15 (-5d) |  | 0d → 0.33d |  | constraint none → finish no later than 2016-07-15 |
| 16 | RUNKOTYÖT VALMIIT | 2016-07-20 → 2016-07-15 (-5d) | 2016-07-20 → 2016-07-15 (-5d) |  | 0d → 0.33d |  |  |
| 17 | **KATTOTYÖT** | 2016-07-20 → 2016-07-15 (-5d) | 2016-07-27 → 2016-07-22 (-5d) |  | 0d → 0.33d |  |  |
| 18 | Kattotuolien asennus | 2016-07-20 → 2016-07-15 (-5d) | 2016-07-25 → 2016-07-20 (-5d) |  | 0d → 0.33d |  | constraint none → start no later than 2016-07-18 |
| 19 | Aluskatteen asnnus | 2016-07-25 → 2016-07-20 (-5d) | 2016-07-26 → 2016-07-21 (-5d) |  | 1d → 2.3d |  |  |
| 20 | Kattotiilien asennus | 2016-07-26 → 2016-07-21 (-5d) | 2016-07-27 → 2016-07-22 (-5d) |  | 4.27d → 5.57d |  |  |
| 21 | KATTOTYÖT VALMIIT | 2016-07-27 → 2016-07-22 (-5d) | 2016-07-27 → 2016-07-22 (-5d) |  | 4.27d → 5.57d |  |  |
| 22 | **VERHOUSTYÖT** | 2016-07-25 → 2016-07-20 (-5d) | 2016-08-02 → 2016-07-28 (-5d) |  | 0d → 0.83d |  |  |
| 23 | Ulkoverhouksen tekeminen | 2016-07-25 → 2016-07-20 (-5d) | 2016-07-27 → 2016-07-22 (-5d) |  | 0d → 0.83d |  |  |
| 24 | Sisäkaton asentaminen | 2016-07-27 → 2016-07-22 (-5d) | 2016-07-28 → 2016-07-25 (-3d) |  | 0d → 1.3d |  |  |
| 25 | Sisäverhouksen tekeminen | 2016-07-28 → 2016-07-25 (-3d) | 2016-08-02 → 2016-07-28 (-5d) |  | 0d → 1.3d |  |  |
| 26 | Sadevesikourujen asennus | 2016-07-27 → 2016-07-22 (-5d) | 2016-07-28 → 2016-07-25 (-3d) |  | 3.27d → 4.57d |  |  |
| 27 | Sähköasennukset | 2016-07-27 → 2016-07-22 (-5d) | 2016-07-28 → 2016-07-25 (-3d) |  | 0d → 1.3d |  |  |
| 28 | Valaisimien asennus | 2016-08-02 → 2016-07-28 (-5d) | 2016-08-02 → 2016-07-28 (-5d) |  | 0d → 1.3d |  |  |
| 29 | Maalaustyöt | 2016-07-27 → 2016-07-22 (-5d) | 2016-08-01 → 2016-07-27 (-5d) |  | 1.27d → 0.83d |  | constraint none → start no later than 2016-07-25 |
| 30 | VERHOUSTYÖT VALMIIT | 2016-08-02 → 2016-07-28 (-5d) | 2016-08-02 → 2016-07-28 (-5d) |  | 0d → 1.3d |  |  |
| 31 | PROJEKTI VALMIS | 2016-08-02 → 2016-07-29 (-4d) | 2016-08-02 → 2016-07-29 (-4d) |  |  |  | constraint none → must finish on 2016-07-29 |

## Version 4 (saved 2015-10-29, file Kalle Kuja - Autotalli 8.mpp)

Last finish stays 2016-07-29.

Changed:

| ID | Task | Other |
| --- | --- | --- |
| 4 | Rakennuspaikan merkitseminen | resources none → Kirvesmies 2; Kirvesmies 1; Apumies |
| 5 | Perustusten kaivuu | resources none → Kaivinkone |
| 6 | Valurungon laudoitus | resources none → Kirvesmies 1; Kirvesmies 2; Apumies [50%] |
| 7 | Raudoitustyö | resources none → Raudoittaja; Apumies [50%] |
| 8 | Raudoitustarkastus | resources none → Kari Keinonen |
| 9 | Perustusten valu | resources none → Kirvesmies 1; Apumies |
| 12 | Valurungon purkaminen | resources none → Kirvesmies 1; Kirvesmies 2; Apumies |
| 13 | Sadevesiviemärien asentaminen | resources none → Kirvesmies 1; Apumies [50%] |
| 14 | Maatyöt (pihan viimeistely) | resources none → Kaivinkone; Apumies [50%] |
| 15 | Kantavan rungon pystytys | resources none → Kirvesmies 2; Apumies [50%] |
| 18 | Kattotuolien asennus | resources none → Kirvesmies 1; Kirvesmies 2; Apumies |
| 19 | Aluskatteen asennus | was named Aluskatteen asnnus; resources none → Kirvesmies 1; Apumies [50%] |
| 20 | Kattotiilien asennus | resources none → Kirvesmies 1; Apumies [50%] |
| 23 | Ulkoverhouksen tekeminen | resources none → Kirvesmies 2; Apumies [50%] |
| 24 | Sisäkaton asentaminen | resources none → Kirvesmies 2; Apumies [50%] |
| 25 | Sisäverhouksen tekeminen | resources none → Kirvesmies 1; Apumies [50%] |
| 26 | Sadevesikourujen asennus | resources none → Kirvesmies 2; Apumies [50%] |
| 27 | Sähköasennukset | resources none → Sähkömies |
| 28 | Valaisimien asennus | resources none → Sähkömies |
| 29 | Maalaustyöt | resources none → Maalari |
| 31 | PROJEKTI VALMIS | resources none → Kari Keinonen |

## Version 5 (saved 2015-10-29, file Kalle Kuja - Autotalli 9.mpp)

Last finish stays 2016-07-29.

Changed:

| ID | Task | Finish | Duration | Total float | Predecessors | Other |
| --- | --- | --- | --- | --- | --- | --- |
| 1 | **Kalle Kuja - autotalli** | 2016-07-04 → 2016-07-28 (+24d) | 0d → 18.43d | none → 0.1d |  |  |
| 7 | Raudoitustyö |  |  |  |  | resources Raudoittaja; Apumies [50%] → Raudoittaja; Apumies [50%]; Teräkset |
| 9 | Perustusten valu |  |  |  |  | resources Kirvesmies 1; Apumies → Kirvesmies 1; Apumies; Betoni |
| 13 | Sadevesiviemärien asentaminen |  |  |  |  | resources Kirvesmies 1; Apumies [50%] → Kirvesmies 1; Apumies [50%]; Sadevesiviemärit |
| 26 | Sadevesikourujen asennus |  |  |  |  | resources Kirvesmies 2; Apumies [50%] → Kirvesmies 2; Apumies [50%]; Sadevesikourut |
| 31 | PROJEKTI VALMIS |  |  |  | 1, 30 → 1FF, 30 |  |

## Version 6 (saved 2015-10-29, file Kalle Kuja - Autotalli 10 maatyÃ¶t.mpp)

Last finish stays 2016-07-29.

Changed:

| ID | Task | Other |
| --- | --- | --- |
| 14 | Maatyöt (pihan viimeistely) | resources Kaivinkone; Apumies [50%] → Kaivinkone; Kalle Kuja [50%] |

## Version 7 (saved 2015-10-29, file Kalle Kuja - Autotalli 10.mpp)

Last finish stays 2016-07-29.

Changed:

| ID | Task | Other |
| --- | --- | --- |
| 13 | Sadevesiviemärien asentaminen | resources Kirvesmies 1; Apumies [50%]; Sadevesiviemärit → Kirvesmies 1; Sadevesiviemärit; Kalle Kuja [50%] |
| 14 | Maatyöt (pihan viimeistely) | resources Kaivinkone; Kalle Kuja [50%] → Kaivinkone; Apumies [50%] |

## Version 8 (saved 2015-10-29, file Kalle Kuja - Autotalli 11.mpp)

Last finish stays 2016-07-29.

Changed:

| ID | Task | Finish | Duration | Total float |
| --- | --- | --- | --- | --- |
| 26 | Sadevesikourujen asennus | 2016-07-25 → 2016-07-26 (+1d) | 1d → 2d | 4.57d → 3.57d |

## Version 9 (saved 2015-10-29, file Kalle Kuja - Autotalli 12.mpp)

Last finish stays 2016-07-29.

Changed:

| ID | Task | Finish | Duration | Total float | Other |
| --- | --- | --- | --- | --- | --- |
| 25 | Sisäverhouksen tekeminen |  |  |  | resources Kirvesmies 1; Apumies [50%] → Kirvesmies 1; Kalle Kuja [50%] |
| 26 | Sadevesikourujen asennus | 2016-07-26 → 2016-07-25 (-1d) | 2d → 1.75d | 3.57d → 3.82d | resources Kirvesmies 2; Apumies [50%]; Sadevesikourut → Kirvesmies 2; Sadevesikourut; Kalle Kuja [50%] |

## Version 10 (saved 2015-10-29, file Kalle Kuja - Autotalli 13.mpp)

Last finish stays 2016-07-29.

Changed:

| ID | Task | Start | Finish | Duration | Total float |
| --- | --- | --- | --- | --- | --- |
| 1 | **Kalle Kuja - autotalli** |  | 2016-07-28 → 2016-07-29 (+1d) | 18.43d → 19.17d |  |
| 22 | **VERHOUSTYÖT** |  | 2016-07-28 → 2016-07-29 (+1d) | 6.27d → 7d | 0.83d → 0.57d |
| 29 | Maalaustyöt |  | 2016-07-27 → 2016-07-29 (+2d) |  | 0.83d → 0.57d |
| 30 | VERHOUSTYÖT VALMIIT | 2016-07-28 → 2016-07-29 (+1d) | 2016-07-28 → 2016-07-29 (+1d) |  | 1.3d → 0.57d |

## Version 11 (saved 2015-10-29, file Kalle Kuja - Autotalli 15.mpp)

Last finish stays 2016-07-29.

Changed:

| ID | Task | Other |
| --- | --- | --- |
| 1 | **Kalle Kuja - autotalli** | baseline start none → 2016-07-04; baseline finish none → 2016-07-29 |
| 2 | PROJEKTIN ALOITUS | baseline start none → 2016-07-04; baseline finish none → 2016-07-04 |
| 3 | **PERUSTUSTYÖT** | baseline start none → 2016-07-04; baseline finish none → 2016-07-08 |
| 4 | Rakennuspaikan merkitseminen | baseline start none → 2016-07-04; baseline finish none → 2016-07-04 |
| 5 | Perustusten kaivuu | baseline start none → 2016-07-04; baseline finish none → 2016-07-04 |
| 6 | Valurungon laudoitus | baseline start none → 2016-07-05; baseline finish none → 2016-07-07 |
| 7 | Raudoitustyö | baseline start none → 2016-07-05; baseline finish none → 2016-07-08 |
| 8 | Raudoitustarkastus | baseline start none → 2016-07-08; baseline finish none → 2016-07-08 |
| 9 | Perustusten valu | baseline start none → 2016-07-08; baseline finish none → 2016-07-08 |
| 10 | PERUSTUSTYÖT VALMIIT | baseline start none → 2016-07-08; baseline finish none → 2016-07-08 |
| 11 | **RUNKOTYÖT** | baseline start none → 2016-07-11; baseline finish none → 2016-07-15 |
| 12 | Valurungon purkaminen | baseline start none → 2016-07-11; baseline finish none → 2016-07-11 |
| 13 | Sadevesiviemärien asentaminen | baseline start none → 2016-07-11; baseline finish none → 2016-07-12 |
| 14 | Maatyöt (pihan viimeistely) | baseline start none → 2016-07-11; baseline finish none → 2016-07-12 |
| 15 | Kantavan rungon pystytys | baseline start none → 2016-07-11; baseline finish none → 2016-07-15 |
| 16 | RUNKOTYÖT VALMIIT | baseline start none → 2016-07-15; baseline finish none → 2016-07-15 |
| 17 | **KATTOTYÖT** | baseline start none → 2016-07-15; baseline finish none → 2016-07-22 |
| 18 | Kattotuolien asennus | baseline start none → 2016-07-15; baseline finish none → 2016-07-20 |
| 19 | Aluskatteen asennus | baseline start none → 2016-07-20; baseline finish none → 2016-07-21 |
| 20 | Kattotiilien asennus | baseline start none → 2016-07-21; baseline finish none → 2016-07-22 |
| 21 | KATTOTYÖT VALMIIT | baseline start none → 2016-07-22; baseline finish none → 2016-07-22 |
| 22 | **VERHOUSTYÖT** | baseline start none → 2016-07-20; baseline finish none → 2016-07-29 |
| 23 | Ulkoverhouksen tekeminen | baseline start none → 2016-07-20; baseline finish none → 2016-07-22 |
| 24 | Sisäkaton asentaminen | baseline start none → 2016-07-22; baseline finish none → 2016-07-25 |
| 25 | Sisäverhouksen tekeminen | baseline start none → 2016-07-25; baseline finish none → 2016-07-28 |
| 26 | Sadevesikourujen asennus | baseline start none → 2016-07-22; baseline finish none → 2016-07-25 |
| 27 | Sähköasennukset | baseline start none → 2016-07-22; baseline finish none → 2016-07-25 |
| 28 | Valaisimien asennus | baseline start none → 2016-07-28; baseline finish none → 2016-07-28 |
| 29 | Maalaustyöt | baseline start none → 2016-07-22; baseline finish none → 2016-07-29 |
| 30 | VERHOUSTYÖT VALMIIT | baseline start none → 2016-07-29; baseline finish none → 2016-07-29 |
| 31 | PROJEKTI VALMIS | baseline start none → 2016-07-29; baseline finish none → 2016-07-29 |

## Version 12 (saved 2015-10-29, file Kalle Kuja - Autotalli 16.mpp)

Last finish stays 2016-07-29.

Added:

| ID | Task | Duration | Start | Finish | Constraint | Resources |
| --- | --- | --- | --- | --- | --- | --- |
| 3 | **Työmaatarkastus** | 17.27d | 2016-07-04 07:00 | 2016-07-27 09:00 |  |  |
| 4 | Työmaatarkastus 1 | 2h | 2016-07-04 07:00 | 2016-07-04 09:00 | start no earlier than 2016-07-04 07:00 | Kari Keinonen |
| 5 | Työmaatarkastus 2 | 2h | 2016-07-06 07:00 | 2016-07-06 09:00 | start no earlier than 2016-07-06 07:00 | Kari Keinonen |
| 6 | Työmaatarkastus 3 | 2h | 2016-07-08 07:00 | 2016-07-08 09:00 | start no earlier than 2016-07-08 07:00 | Kari Keinonen |
| 7 | Työmaatarkastus 4 | 2h | 2016-07-11 07:00 | 2016-07-11 09:00 | start no earlier than 2016-07-11 07:00 | Kari Keinonen |
| 8 | Työmaatarkastus 5 | 2h | 2016-07-13 07:00 | 2016-07-13 09:00 | start no earlier than 2016-07-13 07:00 | Kari Keinonen |
| 9 | Työmaatarkastus 6 | 2h | 2016-07-15 07:00 | 2016-07-15 09:00 | start no earlier than 2016-07-15 07:00 | Kari Keinonen |
| 10 | Työmaatarkastus 7 | 2h | 2016-07-18 07:00 | 2016-07-18 09:00 | start no earlier than 2016-07-18 07:00 | Kari Keinonen |
| 11 | Työmaatarkastus 8 | 2h | 2016-07-20 07:00 | 2016-07-20 09:00 | start no earlier than 2016-07-20 07:00 | Kari Keinonen |
| 12 | Työmaatarkastus 9 | 2h | 2016-07-22 07:00 | 2016-07-22 09:00 | start no earlier than 2016-07-22 07:00 | Kari Keinonen |
| 13 | Työmaatarkastus 10 | 2h | 2016-07-25 07:00 | 2016-07-25 09:00 | start no earlier than 2016-07-25 07:00 | Kari Keinonen |
| 14 | Työmaatarkastus 11 | 2h | 2016-07-27 07:00 | 2016-07-27 09:00 | start no earlier than 2016-07-27 07:00 | Kari Keinonen |

Changed:

| ID | Task | Start | Finish | Other |
| --- | --- | --- | --- | --- |
| 1 | **Kalle Kuja - autotalli** | 2016-07-04 → 2016-07-04 07:00 | 2016-07-29 → 2016-07-29 08:15 | baseline start 2016-07-04 → 2016-07-04 07:00; baseline finish 2016-07-29 → 2016-07-29 08:15 |
| 2 | PROJEKTIN ALOITUS | 2016-07-04 → 2016-07-04 07:00 | 2016-07-04 → 2016-07-04 07:00 | baseline start 2016-07-04 → 2016-07-04 07:00; baseline finish 2016-07-04 → 2016-07-04 07:00 |
| 15 | **PERUSTUSTYÖT** | 2016-07-04 → 2016-07-04 07:00 | 2016-07-08 → 2016-07-08 15:00 | baseline start 2016-07-04 → 2016-07-04 07:00; baseline finish 2016-07-08 → 2016-07-08 15:00 |
| 16 | Rakennuspaikan merkitseminen | 2016-07-04 → 2016-07-04 07:00 | 2016-07-04 → 2016-07-04 15:00 | baseline start 2016-07-04 → 2016-07-04 07:00; baseline finish 2016-07-04 → 2016-07-04 15:00 |
| 17 | Perustusten kaivuu | 2016-07-04 → 2016-07-04 09:00 | 2016-07-04 → 2016-07-04 15:00 | baseline start 2016-07-04 → 2016-07-04 09:00; baseline finish 2016-07-04 → 2016-07-04 15:00 |
| 18 | Valurungon laudoitus | 2016-07-05 → 2016-07-05 07:00 | 2016-07-07 → 2016-07-07 10:45 | baseline start 2016-07-05 → 2016-07-05 07:00; baseline finish 2016-07-07 → 2016-07-07 10:45 |
| 19 | Raudoitustyö | 2016-07-05 → 2016-07-05 10:45 | 2016-07-08 → 2016-07-08 10:45 | baseline start 2016-07-05 → 2016-07-05 10:45; baseline finish 2016-07-08 → 2016-07-08 10:45 |
| 20 | Raudoitustarkastus | 2016-07-08 → 2016-07-08 09:30 | 2016-07-08 → 2016-07-08 12:00 | constraint must start on 2016-07-08 → must start on 2016-07-08 09:30; baseline start 2016-07-08 → 2016-07-08 09:30; baseline finish 2016-07-08 → 2016-07-08 12:00 |
| 21 | Perustusten valu | 2016-07-08 → 2016-07-08 12:00 | 2016-07-08 → 2016-07-08 15:00 | constraint must finish on 2016-07-08 → must finish on 2016-07-08 15:00; baseline start 2016-07-08 → 2016-07-08 12:00; baseline finish 2016-07-08 → 2016-07-08 15:00 |
| 22 | PERUSTUSTYÖT VALMIIT | 2016-07-08 → 2016-07-08 15:00 | 2016-07-08 → 2016-07-08 15:00 | baseline start 2016-07-08 → 2016-07-08 15:00; baseline finish 2016-07-08 → 2016-07-08 15:00 |
| 23 | **RUNKOTYÖT** | 2016-07-11 → 2016-07-11 07:00 | 2016-07-15 → 2016-07-15 12:30 | baseline start 2016-07-11 → 2016-07-11 07:00; baseline finish 2016-07-15 → 2016-07-15 12:30 |
| 24 | Valurungon purkaminen | 2016-07-11 → 2016-07-11 07:00 | 2016-07-11 → 2016-07-11 12:30 | baseline start 2016-07-11 → 2016-07-11 07:00; baseline finish 2016-07-11 → 2016-07-11 12:30 |
| 25 | Sadevesiviemärien asentaminen | 2016-07-11 → 2016-07-11 12:30 | 2016-07-12 → 2016-07-12 08:30 | baseline start 2016-07-11 → 2016-07-11 12:30; baseline finish 2016-07-12 → 2016-07-12 08:30 |
| 26 | Maatyöt (pihan viimeistely) | 2016-07-11 → 2016-07-11 12:30 | 2016-07-12 → 2016-07-12 09:30 | baseline start 2016-07-11 → 2016-07-11 12:30; baseline finish 2016-07-12 → 2016-07-12 09:30 |
| 27 | Kantavan rungon pystytys | 2016-07-11 → 2016-07-11 12:30 | 2016-07-15 → 2016-07-15 12:30 | constraint finish no later than 2016-07-15 → finish no later than 2016-07-15 15:00; baseline start 2016-07-11 → 2016-07-11 12:30; baseline finish 2016-07-15 → 2016-07-15 12:30 |
| 28 | RUNKOTYÖT VALMIIT | 2016-07-15 → 2016-07-15 12:30 | 2016-07-15 → 2016-07-15 12:30 | baseline start 2016-07-15 → 2016-07-15 12:30; baseline finish 2016-07-15 → 2016-07-15 12:30 |
| 29 | **KATTOTYÖT** | 2016-07-15 → 2016-07-15 12:30 | 2016-07-22 → 2016-07-22 08:15 | baseline start 2016-07-15 → 2016-07-15 12:30; baseline finish 2016-07-22 → 2016-07-22 08:15 |
| 30 | Kattotuolien asennus | 2016-07-15 → 2016-07-15 12:30 | 2016-07-20 → 2016-07-20 08:15 | constraint start no later than 2016-07-18 → start no later than 2016-07-18 07:00; baseline start 2016-07-15 → 2016-07-15 12:30; baseline finish 2016-07-20 → 2016-07-20 08:15 |
| 31 | Aluskatteen asennus | 2016-07-20 → 2016-07-20 08:15 | 2016-07-21 → 2016-07-21 08:15 | baseline start 2016-07-20 → 2016-07-20 08:15; baseline finish 2016-07-21 → 2016-07-21 08:15 |
| 32 | Kattotiilien asennus | 2016-07-21 → 2016-07-21 08:15 | 2016-07-22 → 2016-07-22 08:15 | baseline start 2016-07-21 → 2016-07-21 08:15; baseline finish 2016-07-22 → 2016-07-22 08:15 |
| 33 | KATTOTYÖT VALMIIT | 2016-07-22 → 2016-07-22 08:15 | 2016-07-22 → 2016-07-22 08:15 | baseline start 2016-07-22 → 2016-07-22 08:15; baseline finish 2016-07-22 → 2016-07-22 08:15 |
| 34 | **VERHOUSTYÖT** | 2016-07-20 → 2016-07-20 08:15 | 2016-07-29 → 2016-07-29 08:15 | baseline start 2016-07-20 → 2016-07-20 08:15; baseline finish 2016-07-29 → 2016-07-29 08:15 |
| 35 | Ulkoverhouksen tekeminen | 2016-07-20 → 2016-07-20 08:15 | 2016-07-22 → 2016-07-22 08:15 | baseline start 2016-07-20 → 2016-07-20 08:15; baseline finish 2016-07-22 → 2016-07-22 08:15 |
| 36 | Sisäkaton asentaminen | 2016-07-22 → 2016-07-22 08:15 | 2016-07-25 → 2016-07-25 08:15 | baseline start 2016-07-22 → 2016-07-22 08:15; baseline finish 2016-07-25 → 2016-07-25 08:15 |
| 37 | Sisäverhouksen tekeminen | 2016-07-25 → 2016-07-25 08:15 | 2016-07-28 → 2016-07-28 08:15 | baseline start 2016-07-25 → 2016-07-25 08:15; baseline finish 2016-07-28 → 2016-07-28 08:15 |
| 38 | Sadevesikourujen asennus | 2016-07-22 → 2016-07-22 08:15 | 2016-07-25 → 2016-07-25 14:22 | baseline start 2016-07-22 → 2016-07-22 08:15; baseline finish 2016-07-25 → 2016-07-25 14:22 |
| 39 | Sähköasennukset | 2016-07-22 → 2016-07-22 08:15 | 2016-07-25 → 2016-07-25 08:15 | baseline start 2016-07-22 → 2016-07-22 08:15; baseline finish 2016-07-25 → 2016-07-25 08:15 |
| 40 | Valaisimien asennus | 2016-07-28 → 2016-07-28 08:15 | 2016-07-28 → 2016-07-28 10:15 | baseline start 2016-07-28 → 2016-07-28 08:15; baseline finish 2016-07-28 → 2016-07-28 10:15 |
| 41 | Maalaustyöt | 2016-07-22 → 2016-07-22 08:15 | 2016-07-29 → 2016-07-29 08:15 | constraint start no later than 2016-07-25 → start no later than 2016-07-25 07:00; baseline start 2016-07-22 → 2016-07-22 08:15; baseline finish 2016-07-29 → 2016-07-29 08:15 |
| 42 | VERHOUSTYÖT VALMIIT | 2016-07-29 → 2016-07-29 08:15 | 2016-07-29 → 2016-07-29 08:15 | baseline start 2016-07-29 → 2016-07-29 08:15; baseline finish 2016-07-29 → 2016-07-29 08:15 |
| 43 | PROJEKTI VALMIS | 2016-07-29 → 2016-07-29 13:00 | 2016-07-29 → 2016-07-29 15:00 | constraint must finish on 2016-07-29 → must finish on 2016-07-29 15:00; baseline start 2016-07-29 → 2016-07-29 13:00; baseline finish 2016-07-29 → 2016-07-29 15:00 |

## Version 13 (saved 2015-10-29, file Kalle Kuja - Autotalli 17.mpp)

Last finish stays 2016-07-29.

Changed:

| ID | Task | Other |
| --- | --- | --- |
| 3 | **Työmaatarkastus** | baseline start none → 2016-07-04 07:00; baseline finish none → 2016-07-27 09:00 |
| 4 | Työmaatarkastus 1 | baseline start none → 2016-07-04 07:00; baseline finish none → 2016-07-04 09:00 |
| 5 | Työmaatarkastus 2 | baseline start none → 2016-07-06 07:00; baseline finish none → 2016-07-06 09:00 |
| 6 | Työmaatarkastus 3 | baseline start none → 2016-07-08 07:00; baseline finish none → 2016-07-08 09:00 |
| 7 | Työmaatarkastus 4 | baseline start none → 2016-07-11 07:00; baseline finish none → 2016-07-11 09:00 |
| 8 | Työmaatarkastus 5 | baseline start none → 2016-07-13 07:00; baseline finish none → 2016-07-13 09:00 |
| 9 | Työmaatarkastus 6 | baseline start none → 2016-07-15 07:00; baseline finish none → 2016-07-15 09:00 |
| 10 | Työmaatarkastus 7 | baseline start none → 2016-07-18 07:00; baseline finish none → 2016-07-18 09:00 |
| 11 | Työmaatarkastus 8 | baseline start none → 2016-07-20 07:00; baseline finish none → 2016-07-20 09:00 |
| 12 | Työmaatarkastus 9 | baseline start none → 2016-07-22 07:00; baseline finish none → 2016-07-22 09:00 |
| 13 | Työmaatarkastus 10 | baseline start none → 2016-07-25 07:00; baseline finish none → 2016-07-25 09:00 |
| 14 | Työmaatarkastus 11 | baseline start none → 2016-07-27 07:00; baseline finish none → 2016-07-27 09:00 |

## Version 14 (saved 2015-10-29, file Kalle Kuja - Autotalli seuranta 1.mpp)

Last finish stays 2016-07-29. Complete tasks 0 → 11.

Changed:

| ID | Task | Start | Finish | Complete | Total float |
| --- | --- | --- | --- | --- | --- |
| 1 | **Kalle Kuja - autotalli** | 2016-07-04 07:00 A |  | 0% → 26% | 0.1d → 0.83d |
| 2 | PROJEKTIN ALOITUS | 2016-07-04 07:00 A | 2016-07-04 07:00 A | 0% → 100% | 0.1d → none |
| 3 | **Työmaatarkastus** | 2016-07-04 07:00 A |  | 0% → 27% |  |
| 4 | Työmaatarkastus 1 | 2016-07-04 07:00 A | 2016-07-04 09:00 A | 0% → 100% | 19.73d → none |
| 5 | Työmaatarkastus 2 | 2016-07-06 07:00 A | 2016-07-06 09:00 A | 0% → 100% | 17.73d → none |
| 6 | Työmaatarkastus 3 | 2016-07-08 07:00 A | 2016-07-08 09:00 A | 0% → 100% | 15.73d → none |
| 15 | **PERUSTUSTYÖT** | 2016-07-04 07:00 A | 2016-07-08 15:00 A | 0% → 100% | 0d → none |
| 16 | Rakennuspaikan merkitseminen | 2016-07-04 07:00 A | 2016-07-04 15:00 A | 0% → 100% | 0.1d → none |
| 17 | Perustusten kaivuu | 2016-07-04 09:00 A | 2016-07-04 15:00 A | 0% → 100% | 0.1d → none |
| 18 | Valurungon laudoitus | 2016-07-05 07:00 A | 2016-07-07 10:45 A | 0% → 100% | 0.1d → none |
| 19 | Raudoitustyö | 2016-07-05 10:45 A | 2016-07-08 10:45 A | 0% → 100% | 0.1d → none |
| 20 | Raudoitustarkastus | 2016-07-08 09:30 A | 2016-07-08 12:00 A | 0% → 100% | 0d → none |
| 21 | Perustusten valu | 2016-07-08 12:00 A | 2016-07-08 15:00 A | 0% → 100% | 0d → none |
| 22 | PERUSTUSTYÖT VALMIIT | 2016-07-08 15:00 A | 2016-07-08 15:00 A | 0% → 100% | 0.33d → none |

## Version 15 (saved 2015-10-29, file Kalle Kuja - Autotalli seuranta 2.mpp)

Last finish stays 2016-07-29. Complete tasks 11 → 19.

Changed:

| ID | Task | Start | Finish | Duration | Complete | Total float |
| --- | --- | --- | --- | --- | --- | --- |
| 1 | **Kalle Kuja - autotalli** |  |  |  | 26% → 47% |  |
| 3 | **Työmaatarkastus** |  |  |  | 27% → 55% |  |
| 7 | Työmaatarkastus 4 | 2016-07-11 07:00 A | 2016-07-11 09:00 A |  | 0% → 100% | 14.73d → none |
| 8 | Työmaatarkastus 5 | 2016-07-13 07:00 A | 2016-07-13 09:00 A |  | 0% → 100% | 12.73d → none |
| 9 | Työmaatarkastus 6 | 2016-07-15 07:00 A | 2016-07-15 09:00 A |  | 0% → 100% | 10.73d → none |
| 23 | **RUNKOTYÖT** | 2016-07-11 07:00 A | 2016-07-15 12:30 A |  | 0% → 100% | 0.33d → none |
| 24 | Valurungon purkaminen | 2016-07-11 07:00 A | 2016-07-11 12:30 A |  | 0% → 100% | 0.33d → none |
| 25 | Sadevesiviemärien asentaminen | 2016-07-11 12:30 A | 2016-07-12 08:30 A |  | 0% → 100% | 3.8d → none |
| 26 | Maatyöt (pihan viimeistely) | 2016-07-11 12:30 A | 2016-07-12 09:30 A |  | 0% → 100% | 3.67d → none |
| 27 | Kantavan rungon pystytys | 2016-07-11 12:30 A | 2016-07-15 12:30 A |  | 0% → 100% | 0.33d → none |
| 28 | RUNKOTYÖT VALMIIT | 2016-07-15 12:30 A | 2016-07-15 12:30 A |  | 0% → 100% | 0.33d → none |
| 29 | **KATTOTYÖT** | 2016-07-15 12:30 → 2016-07-15 07:00 A |  | 4.5d → 5.17d | 0% → 6% | 0.33d → 5.83d |
| 30 | Kattotuolien asennus | 2016-07-15 12:30 → 2016-07-15 07:00 A |  |  | 0% → 10% | 0.33d → 0.57d |

## Version 16 (saved 2015-10-29, file Kalle Kuja - Autotalli seuranta 3.mpp)

Last finish stays 2016-07-29. Complete tasks 19 → 28.

Changed:

| ID | Task | Start | Finish | Duration | Complete | Total float |
| --- | --- | --- | --- | --- | --- | --- |
| 1 | **Kalle Kuja - autotalli** |  |  |  | 47% → 73% |  |
| 3 | **Työmaatarkastus** |  |  |  | 55% → 82% |  |
| 10 | Työmaatarkastus 7 | 2016-07-18 07:00 A | 2016-07-18 09:00 A |  | 0% → 100% | 9.73d → none |
| 11 | Työmaatarkastus 8 | 2016-07-20 07:00 A | 2016-07-20 09:00 A |  | 0% → 100% | 7.73d → none |
| 12 | Työmaatarkastus 9 | 2016-07-22 07:00 A | 2016-07-22 09:00 A |  | 0% → 100% | 5.73d → none |
| 29 | **KATTOTYÖT** |  | 2016-07-22 08:15 A |  | 6% → 100% | 5.83d → none |
| 30 | Kattotuolien asennus |  | 2016-07-20 08:15 A |  | 10% → 100% | 0.57d → none |
| 31 | Aluskatteen asennus | 2016-07-20 08:15 A | 2016-07-21 08:15 A |  | 0% → 100% | 2.3d → none |
| 32 | Kattotiilien asennus | 2016-07-21 08:15 A | 2016-07-22 08:15 A |  | 0% → 100% | 5.83d → none |
| 33 | KATTOTYÖT VALMIIT | 2016-07-22 08:15 A | 2016-07-22 08:15 A |  | 0% → 100% | 5.83d → none |
| 34 | **VERHOUSTYÖT** | 2016-07-20 08:15 A |  |  | 0% → 26% |  |
| 35 | Ulkoverhouksen tekeminen | 2016-07-20 08:15 A | 2016-07-22 08:15 A |  | 0% → 100% | 0.57d → none |
| 38 | Sadevesikourujen asennus | 2016-07-22 08:15 A | 2016-07-25 14:22 → 2016-07-22 15:00 A (-3d) | 1.75d → 0.83d | 0% → 100% | 3.82d → none |

## Version 17 (saved 2015-10-29, file Kalle Kuja - Autotalli seuranta 4.mpp)

Last finish stays 2016-07-29. Complete tasks 28 → 37.

Changed:

| ID | Task | Start | Finish | Duration | Complete | Total float | Other |
| --- | --- | --- | --- | --- | --- | --- | --- |
| 1 | **Kalle Kuja - autotalli** |  | 2016-07-29 08:15 A |  | 73% → 100% | 0.83d → none |  |
| 3 | **Työmaatarkastus** |  | 2016-07-27 09:00 → 2016-07-27 15:00 A | 17.27d → 18d | 82% → 100% | 2.73d → none | baseline finish 2016-07-27 09:00 → 2016-07-27 15:00 |
| 7 | Työmaatarkastus 4 | 2016-07-11 07:00 A → 2016-07-11 13:00 A | 2016-07-11 09:00 A → 2016-07-11 15:00 A |  |  |  | constraint start no earlier than 2016-07-11 07:00 → finish no earlier than 2016-07-11 15:00; baseline start 2016-07-11 07:00 → 2016-07-11 13:00; baseline finish 2016-07-11 09:00 → 2016-07-11 15:00 |
| 8 | Työmaatarkastus 5 | 2016-07-13 07:00 A → 2016-07-13 13:00 A | 2016-07-13 09:00 A → 2016-07-13 15:00 A |  |  |  | constraint start no earlier than 2016-07-13 07:00 → finish no earlier than 2016-07-13 15:00; baseline start 2016-07-13 07:00 → 2016-07-13 13:00; baseline finish 2016-07-13 09:00 → 2016-07-13 15:00 |
| 9 | Työmaatarkastus 6 | 2016-07-15 07:00 A → 2016-07-15 13:00 A | 2016-07-15 09:00 A → 2016-07-15 15:00 A |  |  |  | constraint start no earlier than 2016-07-15 07:00 → finish no earlier than 2016-07-15 15:00; baseline start 2016-07-15 07:00 → 2016-07-15 13:00; baseline finish 2016-07-15 09:00 → 2016-07-15 15:00 |
| 10 | Työmaatarkastus 7 | 2016-07-18 07:00 A → 2016-07-18 13:00 A | 2016-07-18 09:00 A → 2016-07-18 15:00 A |  |  |  | constraint start no earlier than 2016-07-18 07:00 → finish no earlier than 2016-07-18 15:00; baseline start 2016-07-18 07:00 → 2016-07-18 13:00; baseline finish 2016-07-18 09:00 → 2016-07-18 15:00 |
| 11 | Työmaatarkastus 8 | 2016-07-20 07:00 A → 2016-07-20 13:00 A | 2016-07-20 09:00 A → 2016-07-20 15:00 A |  |  |  | constraint start no earlier than 2016-07-20 07:00 → finish no earlier than 2016-07-20 15:00; baseline start 2016-07-20 07:00 → 2016-07-20 13:00; baseline finish 2016-07-20 09:00 → 2016-07-20 15:00 |
| 12 | Työmaatarkastus 9 | 2016-07-22 07:00 A → 2016-07-22 13:00 A | 2016-07-22 09:00 A → 2016-07-22 15:00 A |  |  |  | constraint start no earlier than 2016-07-22 07:00 → finish no earlier than 2016-07-22 15:00; baseline start 2016-07-22 07:00 → 2016-07-22 13:00; baseline finish 2016-07-22 09:00 → 2016-07-22 15:00 |
| 13 | Työmaatarkastus 10 | 2016-07-25 07:00 → 2016-07-25 13:00 A | 2016-07-25 09:00 → 2016-07-25 15:00 A |  | 0% → 100% | 4.73d → none | constraint start no earlier than 2016-07-25 07:00 → finish no earlier than 2016-07-25 15:00; baseline start 2016-07-25 07:00 → 2016-07-25 13:00; baseline finish 2016-07-25 09:00 → 2016-07-25 15:00 |
| 14 | Työmaatarkastus 11 | 2016-07-27 07:00 → 2016-07-27 13:00 A | 2016-07-27 09:00 → 2016-07-27 15:00 A |  | 0% → 100% | 2.73d → none | constraint start no earlier than 2016-07-27 07:00 → finish no earlier than 2016-07-27 15:00; baseline start 2016-07-27 07:00 → 2016-07-27 13:00; baseline finish 2016-07-27 09:00 → 2016-07-27 15:00 |
| 29 | **KATTOTYÖT** | 2016-07-15 07:00 A → 2016-07-14 07:00 A (-1d) |  | 5.17d → 6.17d |  |  |  |
| 30 | Kattotuolien asennus | 2016-07-15 07:00 A → 2016-07-14 07:00 A (-1d) |  |  |  |  |  |
| 34 | **VERHOUSTYÖT** |  | 2016-07-29 08:15 A |  | 26% → 100% | 0.57d → none |  |
| 36 | Sisäkaton asentaminen | 2016-07-22 08:15 A | 2016-07-25 08:15 A |  | 0% → 100% | 1.3d → none |  |
| 37 | Sisäverhouksen tekeminen | 2016-07-25 08:15 A | 2016-07-28 08:15 A |  | 0% → 100% | 1.3d → none |  |
| 39 | Sähköasennukset | 2016-07-22 08:15 A | 2016-07-25 08:15 A |  | 0% → 100% | 1.3d → none |  |
| 40 | Valaisimien asennus | 2016-07-28 08:15 A | 2016-07-28 10:15 A |  | 0% → 100% | 1.3d → none |  |
| 41 | Maalaustyöt | 2016-07-22 08:15 A | 2016-07-29 08:15 A |  | 0% → 100% | 0.57d → none |  |
| 42 | VERHOUSTYÖT VALMIIT | 2016-07-29 08:15 A | 2016-07-29 08:15 A |  | 0% → 100% | 0.57d → none |  |
| 43 | PROJEKTI VALMIS | 2016-07-29 13:00 A | 2016-07-29 15:00 A |  | 0% → 100% | 0d → none |  |

## Version 18 (saved 2015-10-29, file Kalle Kuja - Autotalli valmis.mpp)

Last finish stays 2016-07-29.

Changed:

| ID | Task | Start | Finish | Duration | Other |
| --- | --- | --- | --- | --- | --- |
| 3 | **Työmaatarkastus** |  | 2016-07-27 15:00 A → 2016-07-27 09:00 A | 18d → 17.27d | baseline finish 2016-07-27 15:00 → 2016-07-27 09:00 |
| 7 | Työmaatarkastus 4 | 2016-07-11 13:00 A → 2016-07-11 07:00 A | 2016-07-11 15:00 A → 2016-07-11 09:00 A |  | constraint finish no earlier than 2016-07-11 15:00 → start no earlier than 2016-07-11 07:00; baseline start 2016-07-11 13:00 → 2016-07-11 07:00; baseline finish 2016-07-11 15:00 → 2016-07-11 09:00 |
| 8 | Työmaatarkastus 5 | 2016-07-13 13:00 A → 2016-07-13 07:00 A | 2016-07-13 15:00 A → 2016-07-13 09:00 A |  | constraint finish no earlier than 2016-07-13 15:00 → start no earlier than 2016-07-13 07:00; baseline start 2016-07-13 13:00 → 2016-07-13 07:00; baseline finish 2016-07-13 15:00 → 2016-07-13 09:00 |
| 9 | Työmaatarkastus 6 | 2016-07-15 13:00 A → 2016-07-15 07:00 A | 2016-07-15 15:00 A → 2016-07-15 09:00 A |  | constraint finish no earlier than 2016-07-15 15:00 → start no earlier than 2016-07-15 07:00; baseline start 2016-07-15 13:00 → 2016-07-15 07:00; baseline finish 2016-07-15 15:00 → 2016-07-15 09:00 |
| 10 | Työmaatarkastus 7 | 2016-07-18 13:00 A → 2016-07-18 07:00 A | 2016-07-18 15:00 A → 2016-07-18 09:00 A |  | constraint finish no earlier than 2016-07-18 15:00 → start no earlier than 2016-07-18 07:00; baseline start 2016-07-18 13:00 → 2016-07-18 07:00; baseline finish 2016-07-18 15:00 → 2016-07-18 09:00 |
| 11 | Työmaatarkastus 8 | 2016-07-20 13:00 A → 2016-07-20 07:00 A | 2016-07-20 15:00 A → 2016-07-20 09:00 A |  | constraint finish no earlier than 2016-07-20 15:00 → start no earlier than 2016-07-20 07:00; baseline start 2016-07-20 13:00 → 2016-07-20 07:00; baseline finish 2016-07-20 15:00 → 2016-07-20 09:00 |
| 12 | Työmaatarkastus 9 | 2016-07-22 13:00 A → 2016-07-22 07:00 A | 2016-07-22 15:00 A → 2016-07-22 09:00 A |  | constraint finish no earlier than 2016-07-22 15:00 → start no earlier than 2016-07-22 07:00; baseline start 2016-07-22 13:00 → 2016-07-22 07:00; baseline finish 2016-07-22 15:00 → 2016-07-22 09:00 |
| 13 | Työmaatarkastus 10 | 2016-07-25 13:00 A → 2016-07-25 07:00 A | 2016-07-25 15:00 A → 2016-07-25 09:00 A |  | constraint finish no earlier than 2016-07-25 15:00 → start no earlier than 2016-07-25 07:00; baseline start 2016-07-25 13:00 → 2016-07-25 07:00; baseline finish 2016-07-25 15:00 → 2016-07-25 09:00 |
| 14 | Työmaatarkastus 11 | 2016-07-27 13:00 A → 2016-07-27 07:00 A | 2016-07-27 15:00 A → 2016-07-27 09:00 A |  | constraint finish no earlier than 2016-07-27 15:00 → start no earlier than 2016-07-27 07:00; baseline start 2016-07-27 13:00 → 2016-07-27 07:00; baseline finish 2016-07-27 15:00 → 2016-07-27 09:00 |
| 29 | **KATTOTYÖT** | 2016-07-14 07:00 A → 2016-07-15 07:00 A (+1d) |  | 6.17d → 5.17d |  |
| 30 | Kattotuolien asennus | 2016-07-14 07:00 A → 2016-07-15 07:00 A (+1d) |  |  |  |
